# Magnet Test

Schedule from MS Project, 2015-03-11 to 2016-11-03, costs in $.
BNL C-AD

## Calendars

- Standard: Mon-Fri 08:00-12:00, 13:00-17:00; Sat-Sun off.

## Resources

| Resource | Group | Rate |
| --- | --- | --- |
| CA-Elect Designer | CAD | 141.87 |
| CA-Mech Designer | CAD | 141.87 |
| Building Trades (Standard) | DT | 146.09 |
| BT Carpenters | DT | 120.59 |
| BT Electrician | DT | 120.59 |
| BT Rigger | DT | 120.59 |
| Central Shops | DT | 177.77 |
| Welder | DT | 177.77 |
| CA-Elect Engineer | CAD | 208.05 |
| CA-Mech Engineer | CAD | 208.05 |
| CA-CAS Tech | CAD | 162.64 |
| CA-Beam & Exp Tech | CAD | 162.64 |
| CA-Survey | CAD | 162.64 |
| PHENIX Tech | sPHENIX | 162.64 |
| CA-Job Shopper Tech | CAD | 82 |
| CA-Vacuum Tech | CAD | 162.64 |
| Dave Phillips | CAD | 208.05 |
| CA-Cryo | CAD |  |
| Magnet Division | SMD |  |
| Wuzheng Meng | CAD | 254.99 |
| sPHENIX | sPHENIX |  |
| Paul Giannotti | sPHENIX | 208.05 |
| Kin Yip | CAD | 254.99 |
| Pablo Rosas | CAD | 208.05 |
| Bob Lambiase | CAD | 208.05 |
| Jon Hock | CAD | 208.05 |
| Achim Franz | sPHENIX | 254.99 |
| Paul Kovach | SMD | 208.05 |
| Mike Anerella | SMD | 208.05 |
| Paul Orfin | CAD | 208.05 |
| Tom Tallerico | CAD | 208.05 |
| Piyush Joshi | SMD | 208.05 |
| CA-Cryo Mech Tech | CAD | 162.64 |
| CA-Cryo Elect Tech | CAD | 162.64 |
| SMD-Tech | SMD | 162.64 |

## Schedule

| ID | WBS | Task | Type | Duration | Start | Finish | Predecessors | Total slack | Free slack | Constraint | Resources | Work | Cost | Manager |
| --- | --- | --- | --- | --- | --- | --- | --- | --- | --- | --- | --- | --- | --- | --- |
| 1 | 52 | **Low Field Test** |  | 140d | 2015-03-11 | 2015-09-22 |  | 0d |  |  |  | 1875.6h | 80,726.8 | Yip |
| 2 | 1.1 | Catalog and Scan Magnet Documentation |  | 10d | 2015-03-11 | 2015-03-24 |  | 0d |  |  | sPHENIX | 80h |  | Giannotti |
| 3 | 1.2 | Shipment of Equipment from SLAC |  | 10d | 2015-03-17 | 2015-03-30 |  | 75d | 0d | start no earlier than 2015-03-17 | Paul Kovach [1%] | 0.8h | 166.44 | Kovach |
| 4 | 52.4 | Off-Load Equipment |  | 1d | 2015-03-31 | 2015-03-31 | 3 | 75d | 0d |  | Dave Phillips [10%] | 0.8h | 166.44 | Phillips |
| 5 | 1.4 | Inspect Shipped Cryo Equipment |  | 5d | 2015-04-01 | 2015-04-07 | 4 | 402d | 0d |  | CA-Cryo | 40h |  | Than |
| 6 | 52.2 | Inspect Power Supply, Dump Resistor, and Controls |  | 10d | 2015-04-07 | 2015-04-21 | 5 | 402d |  |  | Bob Lambiase; Magnet Division | 80h |  | Lambiase |
| 7 | 52.3 | Inspect Valve Box and Mechanical Equipment |  | 5d | 2015-03-31 | 2015-04-07 | 4 | 75d | 0d |  | Magnet Division; CA-Cryo | 40h |  | Anerella |
| 8 | 1.7 | Design Valve Box Support |  | 10d | 2015-04-01 | 2015-04-14 | 4 | 407d |  |  | Dave Phillips [10%] | 8h | 1,664.4 | Phillips |
| 9 | 1.8 | Develop Plan for Safety Reviews |  | 20d | 2015-04-07 | 2015-05-05 | 7 | 292d | 0d |  | Kin Yip; Dave Phillips | 160h | 40,798.4 | Yip |
| 10 | 1.9 | Preliminary Lab Safety & ESRC Review | milestone | 0d | 2015-05-05 | 2015-05-05 | 9 | 292d | 0d |  |  |  |  | Yip |
| 11 | 1.10 | Develop Plan with Cost & Schedule of Low Field Test |  | 30d | 2015-04-08 | 2015-05-19 | 9SS | 382d |  |  | Dave Phillips [10%]; Kin Yip [10%] | 48h | 11,112.96 | Phillips |
| 12 | 1.11 | Prepare for Lab Safety & ESRC Review |  | 40d | 2015-05-06 | 2015-06-30 | 10 | 292d | 0d |  |  |  |  | Yip |
| 13 | 1.12 | Develop Critical Lift Plan and Review |  | 10d | 2015-03-11 | 2015-03-24 |  | 386d | 20d |  | Dave Phillips [10%] | 8h | 1,664.4 | Phillips |
| 14 | 1.13 | Magnet Inspection & Non-powered Acceptance Tests |  | 20d | 2015-03-25 | 2015-04-21 | 2 | 366d | 0d |  | Magnet Division | 160h |  | Anerella |
| 15 | 1.14 | Rotate Magnet |  | 1d | 2015-04-22 | 2015-04-22 | 14, 13 | 366d | 6d |  | Dave Phillips [50%] | 4h | 832.2 | Phillips |
| 16 | 1.15 | Plan for Valve Box Hook-up |  | 15d | 2015-04-08 | 2015-04-28 | 2, 7 | 75d | 0d |  | Magnet Division | 120h |  | Kovach |
| 17 | 1.16 | Install Scafolding (Access for Valve Box) |  | 2d | 2015-04-29 | 2015-04-30 | 16 | 360d | 0d |  | Dave Phillips [25%] | 4h | 832.2 | Phillips |
| 18 | 1.17 | Connect Existing Valve Box (Without Extension) |  | 25d | 2015-05-01 | 2015-06-04 | 15, 17 | 360d | 0d |  | Magnet Division | 200h |  | Anerella |
| 19 | 1.18 | Cryo Hook-up Design and Design Review |  | 25d | 2015-03-25 | 2015-04-28 | 2 | 0d |  |  | CA-Cryo | 200h |  | Than |
| 20 | 52.7 | Cryo Design Approval | milestone | 0d | 2015-04-28 | 2015-04-28 | 19 | 0d |  |  |  |  |  | Yip |
| 21 | 1.20 | Cryo Hook-up |  | 25d | 2015-05-15 | 2015-06-18 | 18FF+10d, 20 | 360d |  |  | CA-Cryo | 200h |  | Than |
| 22 | 1.21 | Power Supply Plan & Set-up |  | 50d | 2015-03-25 | 2015-06-02 | 2 | 372d |  |  | Pablo Rosas [10%] | 40h | 8,322 | Rosas |
| 23 | 1.22 | Instrumentation Plan & Set-up |  | 50d | 2015-03-25 | 2015-06-02 | 2 | 372d |  |  | Pablo Rosas [10%] | 40h | 8,322 | Rosas? |
| 24 | 1.23 | Lab Safety & ESRC Review | milestone | 0d | 2015-07-07 | 2015-07-07 | 12FS+5d, 20 | 292d | 0d |  |  |  |  | Yip |
| 25 | 1.24 | Low Field Magnetic Safety Review Walkthru |  | 5d | 2015-07-08 | 2015-07-14 | 24 | 292d | 0d |  | Kin Yip [10%]; Dave Phillips [10%] | 8h | 1,852.16 | Phillips |
| 26 | 1.25 | Authorize Low Field Test | milestone | 0d | 2015-07-14 | 2015-07-14 | 25 | 292d | 0d |  | Dave Phillips; Kin Yip; sPHENIX |  |  | Yip |
| 27 | 1.26 | Cool Down Magnet |  | 15d | 2015-07-15 | 2015-08-04 | 26 | 292d | 0d |  | CA-Cryo | 120h |  | Than |
| 28 | 1.27 | Run 100A Tests |  | 5d | 2015-08-04 | 2015-08-11 | 27 | 292d | 0d |  | CA-Cryo; Bob Lambiase; Magnet Division; sPHENIX | 90h |  | Yip |
| 29 | 1.28 | Complete Low Field Test | milestone | 0d | 2015-08-11 | 2015-08-11 | 28 | 292d | 0d |  |  |  |  | Yip |
| 30 | 1.29 | Warm Up Magnet |  | 15d | 2015-08-12 | 2015-09-01 | 29 | 292d | 0d |  | CA-Cryo | 120h |  | Than |
| 31 | 1.30 | Disassemble Set-up |  | 15d | 2015-09-02 | 2015-09-22 | 30 | 292d |  |  | Dave Phillips [20%] | 24h | 4,993.2 | Phillips |
| 32 | 52.5 | Review Data and Write Test Results Report |  | 10d | 2015-08-12 | 2015-08-25 | 28 | 312d |  |  | Magnet Division | 80h |  | Anerella |

| ID | WBS | Task | Type | Duration | Start | Finish | Predecessors | Total slack | Free slack | Resources | Work | Cost | Manager |
| --- | --- | --- | --- | --- | --- | --- | --- | --- | --- | --- | --- | --- | --- |
| 33 | 53 | **Full Field Test** |  | 432d | 2015-03-11 | 2016-11-03 |  | 0d |  |  | 7484h | 194,329 | Yip |
| 34 | 53.26 | **Preliminary Design & Test** |  | 105d | 2015-03-11 | 2015-08-04 |  | 5d |  |  | 1328h | 53,687.2 | Phillips |
| 35 | 53.26.1 | Preliminary Return Layout with Pole Tips |  | 15d | 2015-03-11 | 2015-03-31 |  | 5d | 0d | Dave Phillips [20%]; Jon Hock [50%] | 72h | 14,979.6 | Phillips |
| 36 | 53.26.12 | Field & Force Simulations with Pole Tips |  | 10d | 2015-04-01 | 2015-04-14 | 35 | 5d | 0d | Wuzheng Meng [50%] | 40h | 10,199.6 | Meng |
| 37 | 53.26.13 | Analysis of Forces on Magnet Coil |  | 40d | 2015-04-15 | 2015-06-09 | 36 | 5d | 0d | Magnet Division | 320h |  | Anerella |
| 38 | 53.26.14 | Return Steel Carbon Content Analysis |  | 30d | 2015-04-01 | 2015-05-12 | 35 | 30d | 20d | Dave Phillips [5%] | 12h | 2,496.6 | Phillips |
| 39 | 53.26.16 | Return Layout Support Analysis |  | 20d | 2015-04-15 | 2015-05-12 | 36 | 30d | 20d | Jon Hock [25%] | 40h | 8,322 | Hock |
| 40 | 2.1.6 | Complete Preliminary Investigation | milestone | 0d | 2015-06-09 | 2015-06-09 | 35, 36, 37, 38, 39 | 10d | 0d |  |  |  |  |
| 41 | 53.26.2 | **Preliminary Cost Estimates** |  | 30d | 2015-05-27 | 2015-07-07 |  | 20d |  |  | 364h | 7,489.8 | Yip |
| 42 | 53.26.2.8 | Return, Alignment Tooling & Magnet Support Estimate |  | 2d | 2015-06-10 | 2015-06-11 | 40 | 355d | 0d | Dave Phillips | 16h | 3,328.8 | Phillips |
| 43 | 53.26.2.9 | Cryo Hook-up & Operations Estimate |  | 10d | 2015-05-27 | 2015-06-09 | 40FS-10d | 40d | 5d | CA-Cryo | 80h |  | Than |
| 44 | 53.26.2.10 | Valve Box Installation Estimate |  | 10d | 2015-05-27 | 2015-06-09 | 40FS-10d | 40d | 0d | Magnet Division | 80h |  | Kovach |
| 45 | 53.26.2.11 | Power Supply, Dump System & Controls Estimate |  | 10d | 2015-05-27 | 2015-06-09 | 40FS-10d | 20d | 0d | Bob Lambiase; Dave Phillips [15%] | 12h | 2,496.6 | Lambiase |
| 46 | 53.26.2.12 | Quench Detection Estimate |  | 10d | 2015-06-10 | 2015-06-23 | 45 | 20d | 0d | Magnet Division [10%] | 8h |  | Joshi |
| 47 | 53.26.2.15 | Instrumentation Estimate |  | 10d | 2015-06-24 | 2015-07-07 | 46 | 347d |  | Magnet Division | 80h |  | Lambiase |
| 48 | 53.26.2.13 | Field Measurements Estimate |  | 10d | 2015-06-03 | 2015-06-16 | 40FS-5d | 35d | 0d | sPHENIX | 80h |  | Franz |
| 49 | 53.26.2.14 | Disassembly and Clean-up Estimate |  | 10d | 2015-06-12 | 2015-06-25 | 42 | 355d |  | Dave Phillips [10%] | 8h | 1,664.4 | Phillips |
| 50 | 53.26.7 | Final Field and Force Simulations |  | 10d | 2015-06-10 | 2015-06-23 | 40 | 35d | 0d | Wuzheng Meng [50%] | 40h | 10,199.6 | Meng |
| 51 | 53.26.8 | Analysis of Final Forces on Magnet |  | 10d | 2015-06-24 | 2015-07-07 | 50 | 35d | 0d | Magnet Division | 80h |  | Anerella |
| 52 | 53.26.9 | Write Preliminary Test Plan |  | 15d | 2015-06-23 | 2015-07-14 | 43FS+5d, 44FS+5d, 48FS+5d | 35d | 0d | CA-Cryo; Magnet Division; Bob Lambiase; sPHENIX | 360h |  | Yip |
| 53 | 53.26.10 | Review of Design and Test Plan with Ansaldo(?) |  | 10d | 2015-07-08 | 2015-07-21 | 52FS-5d, 51 | 35d | 0d |  |  |  | Yip |
| 54 | 53.26.11 | Preliminary Lab Safety(?) and ESRC Review |  | 10d | 2015-07-22 | 2015-08-04 | 53 | 327d |  |  |  |  | Yip |
| 55 | 53.27 | **Design** |  | 125d | 2015-05-27 | 2015-11-17 |  | 5d |  |  | 2588h | 55,757.4 | Phillips |
| 56 | 53.27.1 | Design Radial Supports |  | 15d | 2015-07-22 | 2015-08-11 | 53 | 35d | 0d | Jon Hock [25%] | 30h | 6,241.5 | Hock |
| 57 | 53.27.2 | Design Axial Supports |  | 15d | 2015-08-12 | 2015-09-01 | 56 | 35d |  | Jon Hock [25%] | 30h | 6,241.5 | Hock |
| 58 | 53.27.5 | Return Steel Design |  | 100d | 2015-05-27 | 2015-10-13 | 37FS-10d | 5d |  | Jon Hock [10%]; Dave Phillips [10%] | 160h | 33,288 | Hock |
| 59 | 53.27.8 | Cryo System Design |  | 100d | 2015-06-03 | 2015-10-20 | 20FS+25d | 0d |  | CA-Cryo | 800h |  | Than |
| 60 | 53.27.12 | Valve Box & Extension Design |  | 50d | 2015-06-10 | 2015-08-18 | 44, 16 | 45d |  | Magnet Division | 400h |  | Kovach |
| 61 | 53.27.11 | Magnetic Measurements Design |  | 40d | 2015-06-17 | 2015-08-11 | 48 | 322d |  | sPHENIX | 320h |  | Franz |
| 62 | 53.27.6 | Mechanical Design Review |  | 5d | 2015-10-21 | 2015-10-27 | 58, 56, 57, 59, 60 | 0d |  |  |  |  | Phillips |
| 63 | 53.27.14 | Complete Mechanical Design | milestone | 0d | 2015-10-27 | 2015-10-27 | 62 | 0d |  |  |  |  |  |
| 64 | 53.27.3 | Power Supply, Dump System & Controls Design |  | 60d | 2015-05-27 | 2015-08-18 | 40FS-10d | 10d | 0d | Bob Lambiase [10%] | 48h | 9,986.4 | Lambiase |
| 65 | 53.27.4 | Quench Detection Design |  | 60d | 2015-07-08 | 2015-09-29 | 46FS+10d | 20d |  | Magnet Division | 480h |  | Joshi |
| 66 | 53.27.9 | Instrumentation Design |  | 40d | 2015-08-19 | 2015-10-13 | 64 | 10d |  | Magnet Division | 320h |  | Lambiase |
| 67 | 53.27.7 | Electrical Design Review |  | 5d | 2015-10-28 | 2015-11-03 | 64, 63, 65, 66 | 0d |  |  |  |  | Phillips |
| 68 | 53.27.15 | Complete Electrical Design | milestone | 0d | 2015-11-03 | 2015-11-03 | 67 | 0d |  |  |  |  |  |
| 69 | 53.27.13 | Lab Safety(?) & ESRC Safety Review |  | 5d | 2015-11-11 | 2015-11-17 | 63, 68FS+5d | 0d |  |  |  |  | Yip |
| 70 | 53.27.16 | Authorize Fabrication and Procurrement | milestone | 0d | 2015-11-17 | 2015-11-17 | 69 | 0d |  |  |  |  | Yip |

| ID | WBS | Task | Type | Duration | Start | Finish | Predecessors | Total slack | Free slack | Resources | Work | Cost | Manager |
| --- | --- | --- | --- | --- | --- | --- | --- | --- | --- | --- | --- | --- | --- |
| 71 | 53.28 | **Fabrication & Procurement** |  | 100d | 2015-11-18 | 2016-04-05 |  | 0d |  |  | 1592h | 48,267.6 | Phillips |
| 72 | 53.28.10 | Return Steel Modifications |  | 100d | 2015-11-18 | 2016-04-05 | 70 | 0d |  | Jon Hock [10%]; Dave Phillips [10%] | 160h | 33,288 | Phillips |
| 73 | 53.28.1 | Fabricate Radial Supports |  | 50d | 2015-12-02 | 2016-02-09 | 70FS+10d | 20d |  | Jon Hock [5%] | 20h | 4,161 | Phillips |
| 74 | 53.28.2 | Fabricate Axial Supports |  | 50d | 2015-12-09 | 2016-02-16 | 70FS+15d | 187d |  | Jon Hock [5%] | 20h | 4,161 | Phillips |
| 75 | 53.28.4 | Cryo Fabrication & Procurements |  | 80d | 2015-12-16 | 2016-04-05 | 70FS+20d | 25d |  | CA-Cryo | 640h |  | Than |
| 76 | 53.28.5 | PS & Controls Refurbishment and Procurements |  | 40d | 2015-11-18 | 2016-01-12 | 70 | 75d |  | Bob Lambiase [10%] | 32h | 6,657.6 | Lambiase |
| 77 | 53.28.6 | QD Fabrication & Procurement |  | 20d | 2015-12-02 | 2015-12-29 | 70FS+10d | 85d |  | Magnet Division | 160h |  | Joshi |
| 78 | 53.28.7 | Instrumentation Fabrication and Procurement |  | 40d | 2015-12-16 | 2016-02-09 | 70FS+20d | 55d |  | Magnet Division | 320h |  | Lambiase |
| 79 | 53.28.8 | Mag Measurement System Fabrication & Procurement |  | 30d | 2015-12-30 | 2016-02-09 | 70FS+30d | 75d | 65d | sPHENIX | 240h |  | Franz |
| 80 | 53.9 | **Assembly & Installation** |  | 110d | 2016-01-27 | 2016-06-28 |  | 0d |  |  | 952h | 31,623.6 | Phillips |
| 81 | 53.9.1 | Assemble Steel Base & Sides |  | 30d | 2016-01-27 | 2016-03-08 | 72FS-50d | 0d |  | Dave Phillips [20%] | 48h | 9,986.4 | Phillips |
| 82 | 53.9.2 | Install Magnet and Supports |  | 10d | 2016-03-09 | 2016-03-22 | 81, 73 | 0d |  | Dave Phillips [20%]; Magnet Division | 96h | 3,328.8 | Phillips |
| 83 | 53.9.3 | Install Top Steel Return |  | 15d | 2016-03-23 | 2016-04-12 | 82 | 0d |  | Dave Phillips [20%] | 24h | 4,993.2 | Phillips |
| 84 | 53.9.4 | Install Valve Box |  | 20d | 2016-04-13 | 2016-05-10 | 83 | 0d |  | Magnet Division | 160h |  | Kovach |
| 85 | 53.9.5 | Install Pole Tips |  | 10d | 2016-05-11 | 2016-05-24 | 84 | 0d |  | Dave Phillips [20%] | 16h | 3,328.8 | Phillips |
| 86 | 53.9.6 | Cryo Installation & Hook-up |  | 30d | 2016-05-11 | 2016-06-21 | 75, 85FS-10d | 0d |  | CA-Cryo | 240h |  | Than |
| 87 | 53.9.7 | PS, Dump System & Controls Installation & Hook-up |  | 30d | 2016-04-27 | 2016-06-07 | 76, 77, 78, 86FF-10d, 84FS-10d | 0d |  | Bob Lambiase [20%] | 48h | 9,986.4 | Lambiase |
| 88 | 53.9.8 | QD Installation & Hook-up |  | 20d | 2016-05-25 | 2016-06-21 | 87FS-10d | 0d |  | Magnet Division | 160h |  | Joshi |
| 89 | 53.9.9 | Mag Measurement System Installation & Hook-up |  | 20d | 2016-05-11 | 2016-06-07 | 79, 84 | 10d |  | sPHENIX | 160h |  | Franz |
| 90 | 53.9.10 | Lab Safety(?) & ESRC Review Walkthru |  | 5d | 2016-06-22 | 2016-06-28 | 86, 87, 88, 89 | 0d |  |  |  |  | Yip |
| 91 | 53.9.13 | Authorize Full Power Test | milestone | 0d | 2016-06-28 | 2016-06-28 | 90 | 0d |  | Dave Phillips; Kin Yip; sPHENIX |  |  | Yip |
| 92 | 53.29 | **Cool Down & Tests** |  | 62d | 2016-06-29 | 2016-09-22 |  | 0d |  |  | 760h |  | Yip |
| 93 | 53.29.1 | Cool Down |  | 15d | 2016-06-29 | 2016-07-19 | 91 | 0d |  | CA-Cryo | 120h |  | Than |
| 94 | 53.29.2 | System tests |  | 10d | 2016-07-19 | 2016-08-02 | 93, 91 | 0d |  | Bob Lambiase; CA-Cryo; Magnet Division | 160h |  | Yip |
| 95 | 53.9.11 | High Field Magnetic Safety Review Walkthru |  | 2d | 2016-08-03 | 2016-08-04 | 94 | 0d |  |  |  |  | Phillips |
| 96 | 53.29.3 | Magnet Ready for Current | milestone | 0d | 2016-08-04 | 2016-08-04 | 95 | 0d |  |  |  |  | Yip |
| 97 | 53.29.4 | Operate Magnet |  | 20d | 2016-08-04 | 2016-09-01 | 96 | 0d |  | Bob Lambiase; CA-Cryo; Magnet Division; sPHENIX | 360h |  | Yip |
| 98 | 2.5.6 | Complete Magnet Test | milestone | 0d | 2016-09-01 | 2016-09-01 | 97 | 45d |  |  |  |  |  |
| 99 | 53.29.5 | Magnet Warm-up |  | 15d | 2016-09-02 | 2016-09-22 | 97 | 0d |  | CA-Cryo | 120h |  | Than |
| 100 | 53.30 | Disassemble & Removal |  | 30d | 2016-09-23 | 2016-11-03 | 99 | 0d |  | Dave Phillips [10%] | 24h | 4,993.2 | Phillips |
| 101 | 53.32 | Compile Operations and Testing Data and Draft Report |  | 30d | 2016-09-23 | 2016-11-03 | 99 | 0d |  | Magnet Division | 240h |  | Anerella |
| 102 | 53.33 | Complete All Work - Full Field Test | milestone | 0d | 2016-11-03 | 2016-11-03 | 100, 101 | 0d |  |  |  |  |  |
